# Diagrama Gantt MYH

Schedule from MS Project, 2007-09-17 to 2008-03-28, costs in €.
IDROBO LUNA

## Calendars

- Estándar: Mon-Fri 09:00-13:00, 15:00-19:00; Sat-Sun off.

## Resources

| Resource | Group | Rate |
| --- | --- | --- |
| Tony Prince | PM | 100 |
| Equipo del proyecto. | Programador | 60 |
| Patrick | Especialista en redes | 60 |
| Nancy | Analista de negocios | 60 |
| Bonnie | Programador | 60 |

## Schedule

| ID | WBS | Task | Type | Duration | Start | Finish | Predecessors | Total slack | Free slack | Constraint | Resources | Work | Cost |
| --- | --- | --- | --- | --- | --- | --- | --- | --- | --- | --- | --- | --- | --- |
| 1 | 1 | **INICIACION** |  | 5d | 2007-09-17 | 2007-09-21 |  | 15d |  |  |  | 40h | 2,400 |
| 2 | 1.1 | Determinar el gerente |  | 1d | 2007-09-17 | 2007-09-17 |  | 15d | 0d |  | Equipo del proyecto. | 8h | 480 |
| 3 | 1.2 | Preparar el Project Charter |  | 4d | 2007-09-18 | 2007-09-21 | 2 | 15d | 0d |  | Equipo del proyecto. | 32h | 1,920 |
| 4 | 2 | **PLANEACION** |  | 24d? | 2007-09-24 | 2007-10-26 |  | 15d |  |  |  | 232h | 14,240 |
| 5 | 2.1 | Realizar reunion inicial |  | 1d | 2007-09-24 | 2007-09-24 | 3 | 15d | 0d | start no earlier than 2007-09-20 | Tony Prince | 8h | 800 |
| 6 | 2.2 | Preparar contrato del equipo |  | 2d | 2007-09-25 | 2007-09-26 | 5 | 22d | 0d | start no earlier than 2007-09-25 | Equipo del proyecto. | 16h | 960 |
| 7 | 2.3 | **Preparar documento del alcance del proyecto** |  | 10d | 2007-09-25 | 2007-10-09 | 5 | 15d |  |  |  | 80h | 4,800 |
| 8 | 2.3.1 | Definir caracteristicas y requerimientos del proyecto. |  | 6d | 2007-09-25 | 2007-10-02 | 5 | 15d | 0d |  | Equipo del proyecto. | 48h | 2,880 |
| 9 | 2.3.2 | Definir entregables del producto |  | 4d | 2007-10-03 | 2007-10-08 | 8 | 15d | 0d | start no earlier than 2007-10-03 | Equipo del proyecto. | 32h | 1,920 |
| 10 | 2.3.3 | Alcance del proyecto | milestone | 0d | 2007-10-09 | 2007-10-09 | 9 | 23d | 8d | start no earlier than 2007-10-09 |  |  |  |
| 11 | 2.4 | Desarrollar el analisis de stakeholders |  | 1d? | 2007-09-27 | 2007-09-27 | 6 | 22d | 7d | start no earlier than 2007-09-27 | Equipo del proyecto. | 8h | 480 |
| 12 | 2.5 | Preparar WBS |  | 2d | 2007-10-09 | 2007-10-10 | 9, 11 | 15d | 0d |  | Equipo del proyecto. | 16h | 960 |
| 13 | 2.6 | WBS | milestone | 0d | 2007-10-11 | 2007-10-11 | 12 | 21d | 6d | start no earlier than 2007-10-11 |  |  |  |
| 14 | 2.7 | **Preprar cronograma y linea base de costos** |  | 6d | 2007-10-11 | 2007-10-19 |  | 15d |  |  |  | 64h | 3,840 |
| 15 | 2.7.1 | Determinar los recursos de las tareas |  | 2d | 2007-10-11 | 2007-10-12 | 12 | 119d |  | start no earlier than 2007-09-28 | Equipo del proyecto. | 16h | 960 |
| 16 | 2.7.2 | Determinar la duracion de las tareas |  | 2d | 2007-10-11 | 2007-10-12 | 12 | 15d | 0d | start no earlier than 2007-09-28 | Equipo del proyecto. | 16h | 960 |
| 17 | 2.7.3 | Determinar las dependencias de las tareas |  | 2d | 2007-10-15 | 2007-10-16 | 16 | 15d | 0d |  | Equipo del proyecto. | 16h | 960 |
| 18 | 2.7.4 | Crear el diagrama de Gantt |  | 2d | 2007-10-17 | 2007-10-18 | 17 | 15d | 0d |  | Equipo del proyecto. | 16h | 960 |
| 19 | 2.7.5 | Cronograma del proyecto | milestone | 0d | 2007-10-19 | 2007-10-19 | 18 | 15d | 0d | start no earlier than 2007-10-19 |  |  |  |
| 20 | 2.8 | Identificar, discutir y priorizar riesgos |  | 3d | 2007-10-19 | 2007-10-23 | 19, 10, 13 | 15d | 0d |  | Equipo del proyecto. | 24h | 1,440 |
| 21 | 2.9 | Crear la matriz de probabilidad e impacto |  | 2d | 2007-10-24 | 2007-10-25 | 20 | 15d | 0d | start no earlier than 2007-10-24 | Equipo del proyecto. | 16h | 960 |
| 22 | 2.10 | Lista de riesgos priorizada | milestone | 0d | 2007-10-26 | 2007-10-26 | 21 | 15d | 0d | start no earlier than 2007-10-26 |  |  |  |
| 23 | 3 | **EJECUCION** |  | 105d | 2007-10-26 | 2008-03-21 |  | 0d |  |  |  | 968h | 63,840 |
| 24 | 3.1 | **Exploraciones** |  | 2d | 2007-10-26 | 2007-10-29 |  | 15d |  |  |  | 40h | 2,720 |
| 25 | 3.1.1 | Exploracion de los incentivos |  | 1d | 2007-10-26 | 2007-10-26 | 19, 22 | 16d | 1d | start no earlier than 2007-10-05 | Tony Prince | 8h | 800 |
| 26 | 3.1.2 | Exploracion de los programas recreacionales de la compañía |  | 2d | 2007-10-26 | 2007-10-29 | 19, 22 | 15d | 0d | start no earlier than 2007-10-15 | Patrick | 16h | 960 |
| 27 | 3.1.3 | Exploracion de las clases sobre salud de la compañía |  | 2d | 2007-10-26 | 2007-10-29 | 19, 22 | 15d | 0d | start no earlier than 2007-10-19 | Nancy | 16h | 960 |
| 28 | 3.1.4 | Documento de contenido de programas y clases | milestone | 0d | 2007-10-29 | 2007-10-29 | 27, 26, 25 | 15d | 0d |  |  |  |  |

| ID | WBS | Task | Type | Duration | Start | Finish | Predecessors | Total slack | Free slack | Constraint | Resources | Work | Cost |
| --- | --- | --- | --- | --- | --- | --- | --- | --- | --- | --- | --- | --- | --- |
| 29 | 3.2 | **Definicion de los requerimientos** |  | 24d | 2007-10-30 | 2007-11-30 |  | 15d |  |  |  | 296h | 19,680 |
| 30 | 3.2.1 | Definicion de los requerimientos de los usuarios |  | 12d | 2007-10-30 | 2007-11-14 | 28 | 15d | 0d | start no earlier than 2007-10-09 | Bonnie | 96h | 5,760 |
| 31 | 3.2.2 | Definicion del contenido de la informacion de las clases de salud patrocinadas |  | 7d | 2007-11-15 | 2007-11-23 | 30 | 17d | 2d |  | Patrick | 56h | 3,360 |
| 32 | 3.2.3 | Definicion del contenido de la informacion de los programas recreacionales patrocinadas |  | 9d | 2007-11-15 | 2007-11-27 | 30 | 15d | 0d | start no earlier than 2007-11-12 | Nancy | 72h | 4,320 |
| 33 | 3.2.4 | Definicion de los incentivos para los empleados participantes |  | 6d | 2007-11-15 | 2007-11-22 | 30 | 18d | 3d | start no earlier than 2007-11-13 | Tony Prince | 48h | 4,800 |
| 34 | 3.2.5 | Definicion de los requerimientos no funcionales del sistema |  | 3d | 2007-11-28 | 2007-11-30 | 31, 32, 33 | 15d | 0d | start no earlier than 2007-11-14 | Bonnie | 24h | 1,440 |
| 35 | 3.2.6 | Definicion de requerimientos del sistema | milestone | 0d | 2007-11-30 | 2007-11-30 | 34 | 15d | 0d |  |  |  |  |
| 36 | 3.3 | **Diseño de la aplicación de la intranet** |  | 22d | 2007-12-03 | 2008-01-01 |  | 15d |  |  |  | 176h | 10,560 |
| 37 | 3.3.1 | Analisis de los casos de uso fincionales |  | 4d | 2007-12-03 | 2007-12-06 | 35 | 15d | 0d | start no earlier than 2007-10-23 | Bonnie | 32h | 1,920 |
| 38 | 3.3.2 | Deficnicion de la arquitectura del sistema |  | 8d | 2007-12-07 | 2007-12-18 | 37 | 15d | 0d |  | Bonnie | 64h | 3,840 |
| 39 | 3.3.3 | Definicion de los prototipos del sistema |  | 10d | 2007-12-19 | 2008-01-01 | 38 | 15d | 0d |  | Bonnie | 80h | 4,800 |
| 40 | 3.3.4 | Arquitectura del sistema | milestone | 0d | 2008-01-01 | 2008-01-01 | 39 | 15d | 0d |  |  |  |  |
| 41 | 3.4 | **Desarrollo de la aplicación de la intranet** |  | 22d | 2008-01-02 | 2008-01-31 |  | 15d |  |  |  | 296h | 20,000 |
| 42 | 3.4.1 | Definicion |  | 7d | 2008-01-02 | 2008-01-10 | 40 | 15d | 0d | start no earlier than 2007-11-01 | Tony Prince | 56h | 5,600 |
| 43 | 3.4.2 | Implementacion |  | 15d | 2008-01-11 | 2008-01-31 | 42 | 15d | 0d |  | Equipo del proyecto.; Bonnie | 240h | 14,400 |
| 44 | 3.4.3 | Sitio Web | milestone | 0d | 2008-01-31 | 2008-01-31 | 43 | 15d | 0d |  |  |  |  |
| 45 | 3.5 | **Pruebas de la aplicación Intranet** |  | 29d | 2008-02-01 | 2008-03-13 |  | 0d |  |  |  | 112h | 8,000 |
| 46 | 3.5.1 | Deficnicion |  | 4d | 2008-02-01 | 2008-02-06 | 44 | 15d | 0d | start no earlier than 2007-12-10 | Tony Prince | 32h | 3,200 |
| 47 | 3.5.2 | Ejecucion |  | 10d | 2008-02-07 | 2008-02-20 | 46 | 15d |  |  | Bonnie | 80h | 4,800 |
| 48 | 3.5.3 | Registro de pruebas aprobadas | milestone | 0d | 2008-03-13 | 2008-03-13 | 47 | 0d |  | start no earlier than 2008-03-13 |  |  |  |
| 49 | 3.6 | Despliegue |  | 3d | 2008-03-13 | 2008-03-17 | 48 | 0d |  | start no earlier than 2007-12-28 | Bonnie | 24h | 1,440 |
| 50 | 3.7 | Soporte |  | 3d | 2008-03-18 | 2008-03-20 | 49 | 0d |  |  | Equipo del proyecto. | 24h | 1,440 |
| 51 | 3.8 | Aplicación integrada | milestone | 0d | 2008-03-21 | 2008-03-21 | 50 | 0d |  | start no earlier than 2008-03-21 |  |  |  |
| 52 | 4 | **CONTROL** |  | 139d | 2007-09-17 | 2008-03-27 |  | 0d |  |  |  | 1112h | 66,720 |
| 53 | 4.1 | Reporte de estado |  | 139d | 2007-09-17 | 2008-03-27 |  | 0d |  | finish no earlier than 2008-03-27 | Equipo del proyecto. | 1112h | 66,720 |

| ID | WBS | Task | Type | Duration | Start | Finish | Predecessors | Total slack | Constraint | Resources | Work | Cost |
| --- | --- | --- | --- | --- | --- | --- | --- | --- | --- | --- | --- | --- |
| 54 | 5 | **CIERRE** |  | 5d | 2008-03-21 | 2008-03-28 |  | 0d |  |  | 104h | 6,240 |
| 55 | 5.1 | Preparacion del reporte final del proyecto |  | 5d | 2008-03-21 | 2008-03-27 | 51 | 0d | start no earlier than 2008-01-07 | Equipo del proyecto. | 40h | 2,400 |
| 56 | 5.2 | Preparacion de la presentacion final del proyecto |  | 4d | 2008-03-21 | 2008-03-26 | 51 | 1d | start no earlier than 2008-03-21 | Equipo del proyecto. | 32h | 1,920 |
| 57 | 5.3 | Lecciones aprendidas |  | 4d | 2008-03-21 | 2008-03-26 | 51 | 1d | start no earlier than 2008-03-21 | Equipo del proyecto. | 32h | 1,920 |
| 58 | 5.4 | FIN | milestone | 0d | 2008-03-28 | 2008-03-28 | 55, 56, 57 | 0d | start no earlier than 2008-03-28 |  |  |  |
